# AxTestPlan

Schedule from MS Project, 2005-04-18 to 2005-05-27.
ASB

## Calendars

- Стандартный: Mon-Fri 09:00-13:00, 14:00-18:00; Sat-Sun off. Exceptions (off unless hours are given): 2005-05-02, 2005-05-09.

## Resources

| Resource |
| --- |
| Гончаренко |
| Котов |
| IBM |
| Разворачивание базы Axapta |
| Мазуркин |

## Schedule

| ID | Task | Duration | Start | Finish | Predecessors | Total slack | Resources | Work |
| --- | --- | --- | --- | --- | --- | --- | --- | --- |
| 1 | Подготовка методики тестирования Axapta | 5d? | 2005-04-18 | 2005-04-22 |  | 0d | Гончаренко | 40h |
| 2 | Разработка спецификации на оборудование | 2d? | 2005-04-18 | 2005-04-19 |  | 0d | Котов | 16h |
| 3 | Подготовка методики тестирования железа | 3d? | 2005-04-20 | 2005-04-22 | 2 | 0d | Котов | 24h |
| 4 | Подготовка тестовой серверной конфигурации №1 | 2d? | 2005-04-25 | 2005-04-26 | 1, 3 | 0d | IBM | 16h |
| 5 | Разворачивание Axapta и наполнение БД для тестов | 3d? | 2005-04-27 | 2005-04-29 | 4 | 0d | Гончаренко | 24h |
| 6 | Тестирование Axapta №1 | 4d? | 2005-05-03 | 2005-05-06 | 5 | 0d | Гончаренко; Котов | 64h |
| 7 | Анализ результатов тестов № 1 материал для Отчета | 4d? | 2005-05-10 | 2005-05-13 | 6 | 0d | Мазуркин; Гончаренко; Котов | 96h |
| 8 | Подготовка тестовой серверной конфигурации № 2 | 2d? | 2005-05-16 | 2005-05-17 | 7 | 0d | IBM | 16h |
| 9 | Тестирование Axapta № 2 | 3d? | 2005-05-18 | 2005-05-20 | 8 | 0d | Гончаренко; Котов | 48h |
| 10 | Анализ результатов тестов № 2 подготовка Отчета | 5d? | 2005-05-23 | 2005-05-27 | 9 | 0d | Мазуркин; Гончаренко; Котов; IBM | 160h |
