# AxTestPlan2

Schedule from MS Project, 2005-04-18 to 2005-05-27.
ASB

## Calendars

- Стандартный: Mon-Fri 09:00-13:00, 14:00-18:00; Sat-Sun off. Exceptions (off unless hours are given): 2005-05-02, 2005-05-09.

## Resources

| Resource |
| --- |
| Гончаренко |
| Котов |
| IBM |
| Разворачивание базы Axapta |
| Мазуркин |

## Schedule

| ID | Task | Duration | Start | Finish | Predecessors | Total slack | Resources | Work |
| --- | --- | --- | --- | --- | --- | --- | --- | --- |
| 1 | Подготовка методики тестирования Axapta | 5d? | 2005-04-18 | 2005-04-22 |  | 0d | Гончаренко | 40h |
| 2 | Разработка спецификации на оборудование | 2d? | 2005-04-18 | 2005-04-19 |  | 0d | Котов | 16h |
| 3 | Подготовка методики тестирования железа | 3d? | 2005-04-20 | 2005-04-22 | 2 | 0d | Котов | 24h |
| 4 | Подготовка тестовой серверной конфигурации №1 | 2d? | 2005-04-25 | 2005-04-26 | 1, 3 | 0d | IBM | 16h |
| 5 | Разворачивание Axapta и наполнение БД для тестов | 3d? | 2005-04-27 | 2005-04-29 | 4 | 0d | Гончаренко | 24h |
| 6 | Тестирование Axapta №1 | 4d? | 2005-05-03 | 2005-05-06 | 5 | 0d | Гончаренко; Котов | 64h |
| 7 | Анализ результатов тестов № 1 материал для Отчета | 4d? | 2005-05-10 | 2005-05-13 | 6 | 0d | Мазуркин; Гончаренко; Котов | 96h |
| 8 | Подготовка тестовой серверной конфигурации № 2 | 2d? | 2005-05-16 | 2005-05-17 | 7 | 0d | IBM | 16h |
| 9 | Тестирование Axapta № 2 | 3d? | 2005-05-18 | 2005-05-20 | 8 | 0d | Гончаренко; Котов | 48h |
| 10 | Анализ результатов тестов № 2 подготовка Отчета | 5d? | 2005-05-23 | 2005-05-27 | 9 | 0d | Мазуркин; Гончаренко; Котов; IBM | 160h |

Notes:
- 1: Вход: / ·нет / Выход: / ·Описание методики тестирования Axapta включая что и как будет измеряться в тестах.
- 2: Вход: / ·нет / Выход: / ·Схема организации тестовых систем (подключения серверов). Вариант № 1 - топовый. Вариант № 2 - средний. / ·Спецификация на оборудование, используемое в тестах.
- 3: Вход: / ·нет / Выход: / ·Описание методики тестирования нагрузки на аппаратные ресурсы и поиска "узких мест" во время теста Axapta
- 4: Вход: / ·Схема организации тестовой системы (подключения серверов). Вариант № 1 - топовый. / ·Спецификация на оборудование, используемое в тесте. / Выход: / ·Тестовая система № 1 подготовлена / ·Windows Server 2003 64-b и SQL Server 2000 Ent Ed 64-b установлены на сервере баз данных / ·Windows Server 2003 32-b установлен на серверах приложений
- 5: Вход: / ·Тестовая система № 1, включая ОС и СУБД подготовлено согласно схеме и спецификации / Выход: / ·База данных Axapta с необходимым объемом (200 <> 500 GB) развернута / ·Сервер приложений Axapta развернут на тестовых серверах приложений / ·Тесты производительности установлены и подготовлены для запуска
- 6: Вход: / ·Тестовая система № 1, ОС, СУБД и Axapta подготовлены для тестирования / Выход: / ·Результаты тестирования Axapta/ ·Результаты тестирования аппаратных ресурсов
- 7: Вход: / ·Результаты тестирования Axapta/ ·Результаты тестирования аппаратных ресурсов / Выход: / ·Первичный анализ результатов для системы № 1 / ·Уточнения по организации тестовой системы № 2 / ·Уточнения по методикам тестирования для тестовой системы № 2 / Комментарий: / ·необходима очная встреча для анализа и brainstorming
- 8: Вход: / ·Уточненая схема организации тестовой системы (подключения серверов). Вариант № 2 - средний. / ·Уточненная спецификация на оборудование, используемое в тесте. / Выход: / ·Тестовая система № 2 подготовлена / ·Windows Server 2003 32-b и SQL Server 2000 Ent Ed 32-b установлены на сервере баз данных / ·Windows Server 2003 32-b установлен на серверах приложений
- 9: Вход: / ·Тестовая система № 2 , ОС, СУБД и Axapta подготовлены для тестирования / Выход: / ·Результаты тестирования Axapta/ ·Результаты тестирования аппаратных ресурсов
- 10: Вход: / ·Результаты тестирования Axapta/ ·Результаты тестирования аппаратных ресурсов / Выход: / ·Анализ результатов для системы № 2 / ·Общий анализ для обоих тестов и определение тенденций / ·Отчет о тестировании, рекомендации по железу, выводы - отчет для публикации / Комментарий: / ·необходима очная встреча в пивбаре для подведения итогов и определения планов на будущее :)
